# TEST

Schedule from MS Project, 2013-04-15 to 2013-08-13, 7.5 hours a day, A marks actual dates.
THPA

## Calendars

- Standard: Mon-Fri 08:00-12:00, 13:00-17:00; Sat-Sun off. Exceptions (off unless hours are given): 2013-05-06 (Bank hol), 2013-05-27 (Bank hol).

## Resources

| Resource | Group |
| --- | --- |
| Pia | Projects |
| Claire | Projects |
| Toby | Projects |
| Natalie | Projects |
| Admin | Admin |
| Alan | Admin |
| Joe | Projects |
| Jenny | Projects |
| Karla | Projects |
| Lorna | Projects |
| Steve | Projects |
| Charlotte | Admin |

## Schedule

| ID | WBS | Task | Duration | Start | Finish | Predecessors | Complete | Remaining | Total slack | Free slack | Constraint | Resources | Work | Actual work |
| --- | --- | --- | --- | --- | --- | --- | --- | --- | --- | --- | --- | --- | --- | --- |
| 1 | 1 | **Project office** | 0.5d | 2013-04-19 A | 2013-04-19 A |  | 100% |  |  |  |  |  | 26.25h | 26.25h |
| 2 | 1.1 | Kick off meeting | 0.5d | 2013-04-19 A | 2013-04-19 A |  | 100% |  |  |  | start no earlier than 2013-04-19 | Alan; Jenny; Joe; Karla; Lorna; Natalie; Pia | 26.25h | 26.25h |
| 3 | 2 | **Letters** | 85.33d | 2013-04-19 A | 2013-08-13 |  | 3% | 82.83d | 0d |  |  |  | 1162.5h | 18.75h |
| 4 | 2.1 | Create letter templates (one type letter, statement, form) | 5d | 2013-04-19 A | 2013-04-26 | 2 | 50% | 2.5d | 0d |  |  | Joe | 37.5h | 18.75h |
| 5 | 2.2 | Review & sign off letter templates | 5d | 2013-04-26 | 2013-05-02 | 4 |  |  | 0d |  |  | Alan; Jenny | 75h |  |
| 6 | 2.3 | Create scheme specific info sheets | 75.33d | 2013-05-02 | 2013-08-13 | 5 |  |  | 0d |  |  | Joe; Admin | 1050h |  |
| 7 | 3 | **Workflows** | 55.5d | 2013-04-15 A | 2013-06-28 |  | 2% | 54.43d | 34.33d |  |  |  | 407.5h | 7.5h |
| 8 | 3.1 | **Early ret from active & deferred (quote)** | 55.5d | 2013-04-15 A | 2013-06-28 |  | 2% | 54.43d | 34.33d |  |  |  | 407.5h | 7.5h |
| 9 | 3.1.1 | Create letters | 1d | 2013-04-15 A | 2013-04-16 A | 2 | 100% |  |  |  |  | Joe | 7.5h | 7.5h |
| 10 | 3.1.2 | Plain english and consistency review letters | 7d | 2013-04-19 | 2013-04-30 | 2 |  |  | 33.87d | 0d |  | Joe | 52.5h |  |
| 11 | 3.1.3 | Technical review of letters | 5d | 2013-04-30 | 2013-05-07 | 10 |  |  | 33.87d | 0d |  | Karla | 13.5h |  |
| 12 | 3.1.4 | Create/amend workflow specification | 7d | 2013-05-07 | 2013-05-16 | 11 |  |  | 33.87d | 0d |  | Karla | 19.25h |  |
| 13 | 3.1.5 | Review & sign off workflow specification & letters | 5d | 2013-05-16 | 2013-05-23 | 12 |  |  | 34.33d | 0d |  | Alan; Jenny; Admin | 112.5h |  |
| 14 | 3.1.6 | Create workflow inc letters | 7d | 2013-05-23 | 2013-06-03 | 13 |  |  | 34.33d | 0d |  | Pia | 52.5h |  |
| 15 | 3.1.7 | Review workflow | 5d | 2013-06-03 | 2013-06-10 | 14 |  |  | 34.33d | 0d |  | Lorna; Steve | 75h |  |
| 16 | 3.1.8 | Testing of workflow inc letters | 10d | 2013-06-10 | 2013-06-21 | 15 |  |  | 34.33d | 0d |  | Joe | 37.25h |  |
| 17 | 3.1.9 | Sign of workflow inc letters | 5d | 2013-06-21 | 2013-06-28 | 16 |  |  | 34.33d |  |  | Alan | 37.5h |  |
